# DPIC-PO-NEC-299-1002

How a schedule from Primavera P6 changed from version to version. A marks actual dates.

## Version 1 (data date 2021-11-11, saved 2021-11-07, file DPIC9812-000-VD-1002-ME-PLN-0002-D0.xer)

| ID | WBS | Task | Duration | Start | Finish | Predecessors | Total float |
| --- | --- | --- | --- | --- | --- | --- | --- |
|  | 1 | **DPIC-PO-NEC-299-1002** |  | 2021-08-11 | 2022-10-04 |  |  |
| 222 |  | Finish | 0d | 2022-10-04 | 2022-10-04 | 221 | 0d |
|  | 1 | **Milestones** |  | 2021-08-11 | 2021-08-11 |  |  |
| 3 |  | LOI Date | 0d | 2021-08-11 | 2021-08-11 |  | 0d |
| 4 |  | Effective Date | 0d | 2021-08-11 | 2021-08-11 | 3 | 0d |
| 5 |  | K.O.M | 0d | 2021-08-11 | 2021-08-11 | 4 | 0d |
| 6 |  | Bank Garanty Payment Date | 0d | 2021-08-11 | 2021-08-11 | 5 | 0d |
| 7 |  | Advanced Payment Date | 0d | 2021-08-11 | 2021-08-11 | 3, 6 | 0d |
|  | 2 | **Engineering** |  | 2021-08-15 | 2022-03-05 |  |  |
|  | 1 | **GENERAL DOCUMENT** |  | 2021-08-15 | 2021-12-19 |  |  |
| 10 |  | Vendor Print Index & Schedule (VPIS) | 21d | 2021-08-15 | 2021-09-04 | 7 FS+4d | 0d |
| 14 |  | Sub Vendor List | 21d | 2021-09-20 | 2021-10-10 | 10 FS+15d | 334d |
| 11 |  | WBS | 21d | 2021-09-25 | 2021-10-15 | 10 FS+20d | 178d |
| 12 |  | Time Schedule | 21d | 2021-11-08 | 2021-11-28 | 11 FS+23d | 264d |
| 13 |  | Project Monthly Report for Refrigeration Packages | 21d | 2021-11-29 | 2021-12-19 | 12 | 264d |
|  | 2 | **ENGINEERING DOCUMENT** |  | 2021-10-17 | 2022-03-05 |  |  |
| 29 |  | Compressor Drawing | 21d | 2021-10-17 | 2021-11-06 | 34 SS | 35d |
| 34 |  | Process Flow Diagram (PFD) | 21d | 2021-10-17 | 2021-11-06 | 10 FS+42d | 0d |
| 57 |  | Compressor Data Sheet | 21d | 2021-10-24 | 2021-11-13 | 29 FS-14d | 35d |
| 59 |  | Process Description | 21d | 2021-10-28 | 2021-11-17 | 34 FS-10d | 254d |
| 39 |  | Condensor Data Sheet | 21d | 2021-10-31 | 2021-11-20 | 34 FS-7d, 10 | 7d |
| 42 |  | Economizer Data Sheet | 21d | 2021-10-31 | 2021-11-20 | 34 FS-7d | 7d |
| 71 |  | Thermal Calculation for Heat Exchangers | 21d | 2021-10-31 | 2021-11-20 | 34 FS-7d | 170d |
| 36 |  | Oil Cooler Data Sheet | 21d | 2021-11-01 | 2021-11-21 | 10, 34 FS-6d | 6d |
| 30 |  | Oil Filter Data Sheet | 21d | 2021-11-07 | 2021-11-27 | 34 | 0d |
| 35 |  | Main Motor Drawing | 21d | 2021-11-07 | 2021-11-27 | 34, 10 | 0d |
| 37 |  | Oil Pump Data Sheet | 21d | 2021-11-07 | 2021-11-27 | 34, 10 | 0d |
| 38 |  | Oil Separator Data Sheet | 21d | 2021-11-07 | 2021-11-27 | 34, 10 | 0d |
| 40 |  | Liquid Receiver Data Sheet | 21d | 2021-11-07 | 2021-11-27 | 34 | 0d |
| 41 |  | K/O Drum Data Sheet | 21d | 2021-11-07 | 2021-11-27 | 34 | 0d |
| 43 |  | Oil Pump Motor Data Sheet | 21d | 2021-11-07 | 2021-11-27 | 34 | 0d |
| 52 |  | Instrument Cable List | 21d | 2021-11-07 | 2021-11-27 | 34, 10 | 35d |
| 61 |  | Instrument Calculations (Safety Relief Valves, Control Valves, Flow Meters, Restriction Orifices, …) | 21d | 2021-11-07 | 2021-11-27 | 34 | 93d |
| 64 |  | Filter Dryer Data Sheet | 21d | 2021-11-07 | 2021-11-27 | 34 | 0d |
| 68 |  | PMS for Compressor Package | 21d | 2021-11-07 | 2021-11-27 | 29 | 209d |
| 82 |  | Material Safety Data Sheet | 21d | 2021-11-07 | 2021-11-27 | 34 | 265d |
| 84 |  | Evaporator Data Sheet | 21d | 2021-11-07 | 2021-11-27 | 34 | 0d |
| 17 |  | Piping and Instrument Diagram (PID) | 30d | 2021-11-12 | 2021-12-11 | 10 FS+68d | 0d |
| 73 |  | Capital Spare Part | 21d | 2021-11-14 | 2021-12-04 | 57 | 279d |
| 74 |  | Special Tools List | 21d | 2021-11-14 | 2021-12-04 | 57 | 279d |
| 85 |  | Evaporator Drawing | 21d | 2021-11-14 | 2021-12-04 | 84 FS-14d | 0d |
| 47 |  | Condensor Drawing | 21d | 2021-11-21 | 2021-12-11 | 39 | 7d |
| 50 |  | Economizer Drawing | 21d | 2021-11-21 | 2021-12-11 | 42 | 7d |
| 44 |  | Oil Cooler Drawing | 21d | 2021-11-22 | 2021-12-12 | 36 | 6d |
| 18 |  | General Arrangement Drawing Including Loads, Displacement, and Maintenace Info | 30d | 2021-11-24 | 2021-12-23 | 17 FS-18d | 0d |
| 20 |  | Utility Consumption List | 21d | 2021-11-27 | 2021-12-17 | 34 FS+20d | 266d |
| 31 |  | Oil Filter Drawing | 21d | 2021-11-28 | 2021-12-18 | 30 | 0d |
| 32 |  | Main Motor Data Sheet and Curve | 21d | 2021-11-28 | 2021-12-18 | 34, 35 | 0d |
| 45 |  | Oil Pump Drawing | 21d | 2021-11-28 | 2021-12-18 | 37 | 0d |
| 46 |  | Oil Separator Drawing | 21d | 2021-11-28 | 2021-12-18 | 38 | 0d |
| 48 |  | Liquid Receiver Drawing | 21d | 2021-11-28 | 2021-12-18 | 40 | 0d |
| 49 |  | K/O Drum Drawing | 21d | 2021-11-28 | 2021-12-18 | 41 | 0d |
| 51 |  | Oil Pump Motor Drawing | 21d | 2021-11-28 | 2021-12-18 | 43 | 0d |
| 65 |  | Filter Dryer Drawing | 21d | 2021-11-28 | 2021-12-18 | 64 | 0d |
| 19 |  | Mechanical Calculation of Heat Exchangers and Pressure Vessles | 21d | 2021-12-05 | 2021-12-25 | 31 FS-14d, 44 FS-14d, 45 FS-14d, 46 FS-14d, 47 FS-14d, 48 FS-14d, 49 FS-14d, 50 FS-14d, 51 FS-14d, 65 FS-14d, 57 FS-14d, 35 FS-14d, 34, 85 | 0d |
| 62 |  | Instrument Hook up Drawings | 21d | 2021-12-10 | 2021-12-30 | 34, 18 FS-14d | 2d |
| 79 |  | Standard Support | 21d | 2021-12-10 | 2021-12-30 | 18 FS-14d | 5d |
| 21 |  | Instrument Index List (Including Alarm & Trip Points) | 21d | 2021-12-12 | 2022-01-01 | 17 | 23d |
| 23 |  | Control Narrative (Sequence Description) | 21d | 2021-12-12 | 2022-01-01 | 17 | 209d |
| 53 |  | Instrument Data Sheets | 21d | 2021-12-12 | 2022-01-01 | 19 FS-14d, 17 | 0d |
| 54 |  | Cause and Effect Diagram | 21d | 2021-12-12 | 2022-01-01 | 17 | 107d |
| 60 |  | Outline Dimensional Drawings (Cabinets Arrangement) | 21d | 2021-12-19 | 2022-01-08 | 18 FS-5d, 34 | 0d |
| 63 |  | Noise Data Sheet | 21d | 2021-12-19 | 2022-01-08 | 32, 57 | 244d |
| 76 |  | Motor Operation & Maintenance Manual | 21d | 2021-12-19 | 2022-01-08 | 32 | 0d |
| 78 |  | Coupling Drawing | 21d | 2021-12-19 | 2022-01-08 | 32 | 0d |
| 24 |  | Spare Parts List for Commissioning & Start-up | 21d | 2021-12-24 | 2022-01-13 | 18 | 239d |
| 25 |  | Spare Parts List for 2-Year Operation | 21d | 2021-12-24 | 2022-01-13 | 18 | 239d |
| 26 |  | IOM(including start up, shut down, precommissioning, commissioning procedure) | 21d | 2021-12-24 | 2022-01-13 | 18, 59 | 218d |
| 58 |  | Equipment List | 21d | 2021-12-24 | 2022-01-13 | 18, 34 | 239d |
| 66 |  | 3D Model | 21d | 2021-12-24 | 2022-01-13 | 18 | 6d |

| ID | WBS | Task | Duration | Start | Finish | Predecessors | Total float |
| --- | --- | --- | --- | --- | --- | --- | --- |
| 70 |  | MTO of Insulation | 21d | 2021-12-24 | 2022-01-13 | 18, 10 | 12d |
| 72 |  | Name Plate Drawing | 21d | 2021-12-24 | 2022-01-13 | 18 | 256d |
| 81 |  | Stress Analysis Report | 21d | 2021-12-24 | 2022-01-13 | 61, 18 | 239d |
| 80 |  | Support List | 21d | 2021-12-31 | 2022-01-20 | 79 | 5d |
| 22 |  | Junction Box Connection Diagrams (Including Wire Schematic to Instruments) | 21d | 2022-01-02 | 2022-01-22 | 21, 18 | 23d |
| 27 |  | I/O List | 21d | 2022-01-02 | 2022-01-22 | 23, 17 | 230d |
| 28 |  | Logic Diagram (Print out PLC Program) | 21d | 2022-01-02 | 2022-01-22 | 34, 23 | 209d |
| 33 |  | PLC Wiring Diagrams | 21d | 2022-01-02 | 2022-01-22 | 54 | 107d |
| 77 |  | ON/OFF Valve Data Sheet | 21d | 2022-01-02 | 2022-01-22 | 53 | 230d |
| 83 |  | PSV Data Sheet | 21d | 2022-01-02 | 2022-01-22 | 53 | 162d |
| 55 |  | Operating Manual (Including Start up, Shut Down, Pre-Commissioning, Commissioning Procedure) | 21d | 2022-01-14 | 2022-02-03 | 26 | 218d |
| 67 |  | Line List | 21d | 2022-01-14 | 2022-02-03 | 17, 66 | 218d |
| 69 |  | Isometrci Drawing for Interconnecting Piping | 21d | 2022-01-14 | 2022-02-03 | 66, 18 | 6d |
| 56 |  | Operating / Control Philosophy | 21d | 2022-01-23 | 2022-02-12 | 28, 17 | 209d |
| 75 |  | LCS Wiring and Drawing | 21d | 2022-01-23 | 2022-02-12 | 22, 34 | 86d |
| 16 |  | Vendor Final Book Index | 21d | 2022-02-13 | 2022-03-05 | 13, 14, 20, 27, 54, 55, 56, 58, 67, 91, 101, 100, 24, 25, 73, 74, 63, 98, 77, 81 | 209d |
|  | 3 | **QC DOCUMENT** |  | 2021-10-18 | 2022-01-28 |  |  |
| 87 |  | Inspection & Test Plan (ITP) (for Whole Package) | 0d | 2021-10-18 | 2021-11-07 | 11 FS+2d | 178d |
| 100 |  | Lifting Procedure | 21d | 2021-11-28 | 2021-12-18 | 87 FS+20d | 265d |
| 101 |  | Certificates (Including Welder Qualification Certificate / NDT Personnel Qualification Certificate, etc.) | 21d | 2021-11-28 | 2021-12-18 | 87 FS+20d | 265d |
| 88 |  | Welding Book (WPS, PQR and Welding / NDE Map) | 21d | 2021-11-28 | 2021-12-18 | 87 FS+20d | 178d |
| 89 |  | Painting Procedure | 21d | 2021-11-28 | 2021-12-18 | 87 FS+20d | 272d |
| 90 |  | Packing, Marking and Shipping Procedure | 21d | 2021-11-28 | 2021-12-18 | 87 FS+20d | 282d |
| 91 |  | Fat Procedure for Control System | 21d | 2021-11-28 | 2021-12-18 | 87 FS+20d | 265d |
| 92 |  | NDE Procedure | 21d | 2021-11-28 | 2021-12-18 | 87 FS+20d | 227d |
| 93 |  | PMI Procedure | 21d | 2021-11-28 | 2021-12-18 | 87 FS+20d | 244d |
| 94 |  | Inspection Notification | 21d | 2021-11-28 | 2021-12-18 | 87 FS+20d | 275d |
| 95 |  | Inspection and Test Plan for Compressor | 21d | 2021-11-28 | 2021-12-18 | 87 FS+20d | 207d |
| 97 |  | Inspection and Test Procedure for Vessle Skids | 21d | 2021-11-28 | 2021-12-18 | 87 FS+20d | 227d |
| 99 |  | Hydrostatic Test Procedure | 21d | 2021-11-28 | 2021-12-18 | 87 FS+20d | 232d |
| 98 |  | Preservation Procedure | 21d | 2021-12-19 | 2022-01-08 | 93, 87, 82 | 244d |
| 96 |  | Inspection and Test Procedure for Compressor | 21d | 2022-01-08 | 2022-01-28 | 95 FS+20d | 207d |
|  | 3 | **Supply of Material** |  | 2021-11-14 | 2022-07-17 |  |  |
|  | 1 | **ForeignSupply** |  | 2021-11-14 | 2022-07-17 |  |  |
|  | 1 | **Special Valves** |  | 2022-01-02 | 2022-06-15 |  |  |
| 105 |  | PO placement (Other Valves) | 10d | 2022-01-02 | 2022-01-11 | 53, 61 | 58d |
| 106 |  | EX Work (Other Valves) | 120d | 2022-01-12 | 2022-05-11 | 105 | 58d |
| 107 |  | Custom clearance (Other Valves) | 30d | 2022-05-12 | 2022-06-10 | 106 | 58d |
| 108 |  | Delivery to shop (Other Valves) | 5d | 2022-06-11 | 2022-06-15 | 107 | 58d |
|  | 2 | **Instrument** |  | 2022-01-02 | 2022-04-16 |  |  |
| 110 |  | PO placement (Instrument) | 10d | 2022-01-02 | 2022-01-11 | 53, 52, 62 | 0d |
| 111 |  | EX Work (Instrument) | 60d | 2022-01-12 | 2022-03-12 | 110 | 0d |
| 112 |  | Custom clearance (Instrument) | 30d | 2022-03-13 | 2022-04-11 | 111 | 0d |
| 113 |  | Delivery to shop (Instrument) | 5d | 2022-04-12 | 2022-04-16 | 112 | 0d |
|  | 3 | **Electrical (Electro motor)** |  | 2022-01-09 | 2022-07-17 |  |  |
| 115 |  | PO placement (Electrical (Electro motor)) | 10d | 2022-01-09 | 2022-01-18 | 32, 34, 35, 60, 76, 78 | 0d |
| 116 |  | EX Work (Electrical (Electro motor)) | 150d | 2022-01-19 | 2022-06-17 | 115 | 0d |
| 117 |  | Custom clearance (Electrical (Electro motor)) | 25d | 2022-06-18 | 2022-07-12 | 116 | 0d |
| 118 |  | Delivery to shop (Electrical (Electro motor)) | 5d | 2022-07-13 | 2022-07-17 | 117 | 0d |
|  | 4 | **Filter** |  | 2021-12-19 | 2022-04-02 |  |  |
| 120 |  | PO placement (Filter) | 10d | 2021-12-19 | 2021-12-28 | 65, 31 | 132d |
| 121 |  | EX Work (Filter) | 60d | 2021-12-29 | 2022-02-26 | 120 | 132d |
| 122 |  | Custom clearance (Filter) | 30d | 2022-02-27 | 2022-03-28 | 121 | 132d |
| 123 |  | Delivery to shop (Filter) | 5d | 2022-03-29 | 2022-04-02 | 122 | 132d |
|  | 5 | **Oil pump & Oil separator** |  | 2021-12-19 | 2022-06-16 |  |  |
| 125 |  | PO placement (Oil pump & Oil separator) | 10d | 2021-12-19 | 2021-12-28 | 45, 46, 44, 51 | 8d |
| 126 |  | EX Work (Oil pump & Oil separator) | 140d | 2021-12-29 | 2022-05-17 | 125 | 8d |
| 127 |  | Custom clearance (Oil pump & Oil separator) | 25d | 2022-05-18 | 2022-06-11 | 126 | 8d |
| 128 |  | Delivery to shop (Oil pump & Oil separator) | 5d | 2022-06-12 | 2022-06-16 | 127 | 8d |
|  | 6 | **Compressor** |  | 2021-11-14 | 2022-05-17 |  |  |
| 130 |  | PO placement (Compressor) | 10d | 2021-11-14 | 2021-11-23 | 34, 57 | 38d |
| 131 |  | EX Work (Compressor) | 140d | 2021-11-24 | 2022-04-12 | 130 | 38d |
| 132 |  | Custom clearance (Compressor) | 30d | 2022-04-13 | 2022-05-12 | 131 | 38d |
| 133 |  | Delivery to shop (Compressor) | 5d | 2022-05-13 | 2022-05-17 | 132 | 38d |
|  | 7 | **Other material** |  | 2021-12-24 | 2022-06-06 |  |  |
| 135 |  | PO placement (other material) | 10d | 2021-12-24 | 2022-01-02 | 18 | 12d |
| 136 |  | EX Work (Other material) | 120d | 2022-01-03 | 2022-05-02 | 135 | 12d |
| 137 |  | Custom clearance (Other material) | 30d | 2022-05-03 | 2022-06-01 | 136 | 12d |
| 138 |  | Delivery to shop (Other material) | 5d | 2022-06-02 | 2022-06-06 | 137 | 12d |
|  | 2 | **Domestic Supply** |  | 2021-12-24 | 2022-03-24 |  |  |

| ID | WBS | Task | Duration | Start | Finish | Predecessors | Total float |
| --- | --- | --- | --- | --- | --- | --- | --- |
|  | 1 | **Pipe** |  | 2022-02-04 | 2022-02-28 |  |  |
| 141 |  | PO placement (Pipe) | 5d | 2022-02-04 | 2022-02-08 | 18, 17, 69 | 6d |
| 142 |  | EX Work (Pipe) | 15d | 2022-02-09 | 2022-02-23 | 141 | 6d |
| 143 |  | Delivery to shop (Pipe) | 5d | 2022-02-24 | 2022-02-28 | 142 | 6d |
|  | 2 | **Plate** |  | 2021-12-24 | 2022-01-17 |  |  |
| 145 |  | PO placement (Plate) | 5d | 2021-12-24 | 2021-12-28 | 18 | 48d |
| 146 |  | EX Work (Plate) | 15d | 2021-12-29 | 2022-01-12 | 145 | 48d |
| 147 |  | Delivery to shop (Plate) | 5d | 2022-01-13 | 2022-01-17 | 146 | 48d |
|  | 3 | **Flange & Fitting** |  | 2021-12-24 | 2022-01-17 |  |  |
| 149 |  | PO placement (Flange & Fitting) | 5d | 2021-12-24 | 2021-12-28 | 18 | 48d |
| 150 |  | EX Work (Flange & Fitting) | 15d | 2021-12-29 | 2022-01-12 | 149 | 48d |
| 151 |  | Delivery to shop (Flange & Fitting) | 5d | 2022-01-13 | 2022-01-17 | 150 | 48d |
|  | 4 | **Gasket** |  | 2021-12-24 | 2022-01-17 |  |  |
| 153 |  | PO placement (Gasket) | 5d | 2021-12-24 | 2021-12-28 | 18 | 48d |
| 154 |  | EX Work (Gasket) | 15d | 2021-12-29 | 2022-01-12 | 153 | 48d |
| 155 |  | Delivery to shop (Gasket) | 5d | 2022-01-13 | 2022-01-17 | 154 | 48d |
|  | 5 | **Bolt & Nut** |  | 2021-12-24 | 2022-01-17 |  |  |
| 157 |  | PO placement (Bolt & Nut) | 5d | 2021-12-24 | 2021-12-28 | 18 | 207d |
| 158 |  | EX Work (Bolt & Nut) | 15d | 2021-12-29 | 2022-01-12 | 157 | 207d |
| 159 |  | Delivery to shop (Bolt & Nut) | 5d | 2022-01-13 | 2022-01-17 | 158 | 207d |
|  | 6 | **Electrical** |  | 2022-01-23 | 2022-03-03 |  |  |
| 161 |  | PO placement (Electrical) | 5d | 2022-01-23 | 2022-01-27 | 18, 22 | 23d |
| 162 |  | EX Work (Electrical) | 30d | 2022-01-28 | 2022-02-26 | 161 | 23d |
| 163 |  | Delivery to shop (Electrical) | 5d | 2022-02-27 | 2022-03-03 | 162 | 23d |
|  | 7 | **Manual valves** |  | 2022-01-23 | 2022-03-03 |  |  |
| 165 |  | PO placement (Manual valves) | 5d | 2022-01-23 | 2022-01-27 | 18, 61, 83 | 162d |
| 166 |  | EX Work (Manual valves) | 30d | 2022-01-28 | 2022-02-26 | 165 | 162d |
| 167 |  | Delivery to shop (Manual valves) | 5d | 2022-02-27 | 2022-03-03 | 166 | 162d |
|  | 8 | **Instrument** |  | 2022-01-02 | 2022-02-10 |  |  |
| 169 |  | PO placement (Domestic Instrument) | 5d | 2022-01-02 | 2022-01-06 | 53, 18 | 24d |
| 170 |  | EX Work (Domestic Instrument) | 30d | 2022-01-07 | 2022-02-05 | 169 | 24d |
| 171 |  | Delivery to shop (Domestic Instrument) | 5d | 2022-02-06 | 2022-02-10 | 170 | 24d |
|  | 9 | **PLC** |  | 2022-02-13 | 2022-03-24 |  |  |
| 173 |  | PO placement (PLC) | 5d | 2022-02-13 | 2022-02-17 | 33, 18, 75 | 86d |
| 174 |  | EX Work (PLC) | 30d | 2022-02-18 | 2022-03-19 | 173 | 86d |
| 175 |  | Delivery to shop (PLC) | 5d | 2022-03-20 | 2022-03-24 | 174 | 86d |
|  | 10 | **Other material** |  | 2022-01-21 | 2022-03-01 |  |  |
| 177 |  | PO placement (Other material (Domestic) ) | 5d | 2022-01-21 | 2022-01-25 | 18, 70, 80 | 5d |
| 178 |  | EX Work (Other material(Domestic)) | 30d | 2022-01-26 | 2022-02-24 | 177 | 5d |
| 179 |  | Delivery to shop (Other material(Domestic)) | 5d | 2022-02-25 | 2022-03-01 | 178 | 5d |
|  | 4 | **Fabrication** |  | 2022-01-18 | 2022-09-26 |  |  |
| 214 |  | Visual & DIM. Inspection | 3d | 2022-09-14 | 2022-09-16 | 213 | 0d |
| 215 |  | Surface Preparation | 3d | 2022-09-17 | 2022-09-19 | 214, 89 | 0d |
| 216 |  | Painting | 5d | 2022-09-20 | 2022-09-24 | 215, 89, 94 | 0d |
| 217 |  | Final Check | 2d | 2022-09-25 | 2022-09-26 | 216 | 0d |
|  | 1 | **Fabrication For Compressor unit** |  | 2022-03-02 | 2022-08-28 |  |  |
| 183 |  | Oil filter | 130d | 2022-03-02 | 2022-07-09 | 143, 147, 151, 155, 179, 171 | 5d |
| 184 |  | Oil cooler | 130d | 2022-03-02 | 2022-07-09 | 143, 147, 151, 155, 179, 171 | 5d |
| 185 |  | Filter dryer | 130d | 2022-03-02 | 2022-07-09 | 143, 147, 151, 155, 179, 171 | 5d |
| 182 |  | Compressor unit Fabrication | 20d | 2022-06-25 | 2022-07-14 | 133, 128, 118 FS-23d, 113, 171, 68 | 0d |
| 186 |  | Part Assembly | 20d | 2022-07-15 | 2022-08-03 | 183, 184, 185, 182 | 0d |
| 187 |  | Part Welding | 20d | 2022-08-04 | 2022-08-23 | 186, 88 | 0d |
| 188 |  | Running test | 5d | 2022-08-24 | 2022-08-28 | 187, 96 | 0d |
|  | 2 | **Fabrication For Condensor** |  | 2022-03-27 | 2022-08-12 |  |  |
| 190 |  | Part Fabrication-(cutting,rolling,casting) | 30d | 2022-03-27 | 2022-04-25 | 143, 147, 151, 155, 163, 171, 113 FS-21d, 47 | 0d |
| 191 |  | Part Assembly | 50d | 2022-04-26 | 2022-06-14 | 190 | 0d |
| 192 |  | Part Welding | 25d | 2022-06-15 | 2022-08-09 | 191, 88 | 0d |
| 193 |  | NDT Condensor | 3d | 2022-08-10 | 2022-08-12 | 192, 92 | 0d |
|  | 3 | **Fabrication For Hexane chiller** |  | 2022-03-31 | 2022-08-12 |  |  |
| 195 |  | Part Fabrication-(cutting,rolling,casting) | 40d | 2022-03-31 | 2022-05-09 | 143, 147, 151, 155, 163, 171, 113 FS-17d | 0d |
| 196 |  | Part Assembly | 65d | 2022-05-10 | 2022-07-13 | 195, 71 | 0d |
| 197 |  | Part Welding | 25d | 2022-07-14 | 2022-08-07 | 196, 88 | 0d |
| 198 |  | NDT Hexane chiller | 5d | 2022-08-08 | 2022-08-12 | 197, 92 | 0d |
|  | 4 | **Fabrication For Skid** |  | 2022-01-18 | 2022-03-28 |  |  |
| 200 |  | Part Fabrication-(cutting,rolling,casting) | 20d | 2022-01-18 | 2022-02-06 | 147 | 137d |
| 201 |  | Part Assembly | 20d | 2022-02-07 | 2022-02-26 | 200 | 137d |
| 202 |  | Part Welding | 20d | 2022-02-27 | 2022-03-18 | 201, 88 | 137d |
| 203 |  | NDT Skid | 10d | 2022-03-19 | 2022-03-28 | 202, 92, 97 | 137d |
|  | 5 | **Fabrication For Other** |  | 2022-06-11 | 2022-08-04 |  |  |
| 205 |  | Part Fabrication-(cutting,rolling,casting) | 20d | 2022-06-11 | 2022-06-30 | 143, 147, 151, 155, 179, 163, 171, 175, 128 FS-6d, 138 | 8d |

| ID | WBS | Task | Duration | Start | Finish | Predecessors | Total float |
| --- | --- | --- | --- | --- | --- | --- | --- |
| 206 |  | Part Assembly | 15d | 2022-07-01 | 2022-07-15 | 205 | 8d |
| 207 |  | Part Welding | 15d | 2022-07-16 | 2022-07-30 | 206, 88 | 8d |
| 208 |  | Hydro test | 5d | 2022-07-31 | 2022-08-04 | 207, 99 | 8d |
|  | 6 | **Assembly of packages on skid** |  | 2022-08-13 | 2022-09-13 |  |  |
| 210 |  | Inter connecting piping | 15d | 2022-08-13 | 2022-08-27 | 188 FS-16d, 193, 198, 203, 167, 108, 123, 159, 208 | 0d |
| 211 |  | Part Assembly | 5d | 2022-08-28 | 2022-09-01 | 210 | 0d |
| 212 |  | Part Welding | 7d | 2022-09-02 | 2022-09-08 | 211, 88 | 0d |
| 213 |  | NDT packages on skid | 5d | 2022-09-09 | 2022-09-13 | 212, 92 | 0d |
|  | 5 | **FINAL INSPECTION TEST and RELEASE NOTE for Ex-Work** |  | 2022-09-27 | 2022-09-30 |  |  |
| 219 |  | FINAL INSPECTION TEST and RELEASE NOTE for Ex-Work | 4d | 2022-09-27 | 2022-09-30 | 217, 90, 72 | 0d |
|  | 6 | **Final Data Book** |  | 2022-10-01 | 2022-10-04 |  |  |
| 221 |  | VENDOR FINAL DATA BOOK | 4d | 2022-10-01 | 2022-10-04 | 219, 16 | 0d |

## Version 2 (data date 2021-11-28, saved 2021-11-28, file DPIC9812-000-VD-1002-ME-PLN-0002-D1.xer)

Last finish stays 2022-10-04. Complete tasks 0 → 2.

Changed:

| ID | Task | Start | Finish | Duration | Complete | Total float | Predecessors | Other |
| --- | --- | --- | --- | --- | --- | --- | --- | --- |
| 1 | **Milestones** |  | 2021-08-11 → 2021-09-14 (+34d) |  |  |  |  |  |
| 6 | Bank Garanty Payment Date |  |  |  |  |  | 5 → 4 |  |
| 5 | K.O.M | 2021-08-11 → 2021-09-14 (+34d) | 2021-08-11 → 2021-09-14 (+34d) |  |  | 0d → 137.75d | 4 → 4 FS+34d |  |
| 2 | **Engineering** |  | 2022-03-05 → 2022-03-20 (+15d) |  |  |  |  |  |
| 1 | **GENERAL DOCUMENT** |  | 2021-12-19 → 2021-10-12 (-68d) |  |  |  |  |  |
| 10 | Vendor Print Index & Schedule (VPIS) | 2021-08-15 A |  | 21d → 20.88d | 0% → 80% |  |  | resources none → (New Resource) |
| 14 | Sub Vendor List | 2021-09-20 → 2021-09-19 (-1d) |  |  |  |  |  | resources none → (New Resource) |
| 11 | WBS | 2021-09-25 → 2021-09-21 (-4d) | 2021-10-15 → 2021-10-11 (-4d) |  |  | 178d → 137.75d | 10 FS+20d → 5 FS+7d | resources none → (New Resource) |
| 12 | Time Schedule | 2021-11-08 → 2021-10-12 A (-27d) | 2021-11-28 → 2021-10-12 (-47d) | 21d → 39.88d | 0% → 60% | 264d → 332.88d | 11 FS+23d → 11 | resources none → (New Resource) |
| 13 | Project Monthly Report for Refrigeration Packages | 2021-11-29 → 2021-11-02 A (-27d) | 2021-12-19 → 2021-10-12 (-68d) | 21d → 30d | 0% → 60% | 264d → 332.88d |  | resources none → (New Resource) |
| 2 | **ENGINEERING DOCUMENT** | 2021-10-17 → 2021-08-29 (-49d) | 2022-03-05 → 2022-03-20 (+15d) |  |  |  |  |  |
| 29 | Compressor Drawing | 2021-10-17 → 2021-08-29 (-49d) | 2021-11-06 → 2021-11-26 (+20d) | 21d → 90d |  | 35d → 5.75d | 34 SS → 34 SS-49d | resources none → (New Resource) |
| 34 | Process Flow Diagram (PFD) |  | 2021-11-06 → 2021-12-15 (+39d) | 21d → 60d |  |  |  | resources none → (New Resource) |
| 39 | Condensor Data Sheet |  |  | 21d → 20.88d |  | 7d → 18.25d | 34 FS-7d, 10 → 34 FS-46d, 10 | resources none → (New Resource) |
| 42 | Economizer Data Sheet |  |  | 21d → 20.88d |  | 7d → 17.25d | 34 FS-7d → 34 FS-46d | resources none → (New Resource) |
| 71 | Thermal Calculation for Heat Exchangers |  | 2021-11-20 → 2021-12-19 (+29d) | 21d → 50d |  | 170d → 158.75d | 34 FS-7d → 34 FS-46d | resources none → (New Resource) |
| 36 | Oil Cooler Data Sheet |  |  |  |  | 6d → 17.12d | 10, 34 FS-6d → 10, 34 FS-45d | resources none → (New Resource) |
| 84 | Evaporator Data Sheet |  | 2021-11-27 → 2021-12-06 (+9d) | 21d → 30d |  | 0d → 21.12d | 34 → 34 FS-39d | resources none → (New Resource) |
| 17 | Piping and Instrument Diagram (PID) | 2021-11-12 → 2021-11-11 A (-1d) |  | 30d → 29.88d | 0% → 60% |  |  | resources none → (New Resource) |
| 41 | K/O Drum Data Sheet | 2021-11-07 → 2021-11-21 (+14d) | 2021-11-27 → 2021-12-11 (+14d) | 21d → 20.88d |  | 0d → 6.12d | 34 → 34 FS-25d | resources none → (New Resource) |
| 35 | Main Motor Drawing | 2021-11-07 → 2021-11-23 (+16d) | 2021-11-27 → 2021-12-13 (+16d) | 21d → 20.88d |  | 0d → 25.12d | 34, 10 → 34 FS-23d, 10 FS+16d | resources none → (New Resource) |
| 18 | General Arrangement Drawing Including Loads, Displacement, and Maintenace Info | 2021-11-24 → 2021-11-23 (-1d) |  |  |  |  |  | resources none → (New Resource) |
| 52 | Instrument Cable List | 2021-11-07 → 2021-11-25 (+18d) | 2021-11-27 → 2021-12-15 (+18d) | 21d → 20.88d |  | 35d → 58.88d | 34, 10 → 34 FS-21d, 10 FS+60d | resources none → (New Resource) |
| 61 | Instrument Calculations (Safety Relief Valves, Control Valves, Flow Meters, Restriction Orifices, …) | 2021-11-07 → 2021-11-25 (+18d) | 2021-11-27 → 2021-12-15 (+18d) |  |  | 93d → 86.75d | 34 → 34 FS-21d | resources none → (New Resource) |
| 20 | Utility Consumption List |  |  |  |  | 266d → 265.88d | 34 FS+20d → 34 FS-19d | resources none → (New Resource) |
| 40 | Liquid Receiver Data Sheet | 2021-11-07 → 2021-11-27 (+20d) | 2021-11-27 → 2021-12-17 (+20d) |  |  | 0d → 11.12d | 34 → 34 FS-19d | resources none → (New Resource) |
| 57 | Compressor Data Sheet | 2021-10-24 → 2021-11-27 (+34d) | 2021-11-13 → 2021-12-17 (+34d) |  |  | 35d → 5.75d | 29 FS-14d → 29 | resources none → (New Resource) |
| 59 | Process Description | 2021-10-28 → 2021-11-27 (+30d) | 2021-11-17 → 2021-12-17 (+30d) |  |  | 254d → 251.88d | 34 FS-10d → 34 FS-19d | resources none → (New Resource) |
| 85 | Evaporator Drawing | 2021-11-14 → 2021-11-27 (+13d) | 2021-12-04 → 2021-12-17 (+13d) | 21d → 20.88d |  | 0d → 21.12d | 84 FS-14d → 84 FS-10d | resources none → (New Resource) |
| 32 | Main Motor Data Sheet and Curve |  |  | 21d → 20.88d |  |  | 34, 35 → 34 FS-18d | resources none → (New Resource) |
| 37 | Oil Pump Data Sheet | 2021-11-07 → 2021-11-30 (+23d) | 2021-11-27 → 2021-12-20 (+23d) |  |  | 0d → 18.12d | 34, 10 → 34 FS-16d, 10 FS+23d | resources none → (New Resource) |
| 38 | Oil Separator Data Sheet | 2021-11-07 → 2021-11-30 (+23d) | 2021-11-27 → 2021-12-20 (+23d) |  |  | 0d → 18.12d | 34, 10 → 34 FS-16d, 10 FS+23d | resources none → (New Resource) |
| 45 | Oil Pump Drawing | 2021-11-28 → 2021-11-30 (+2d) | 2021-12-18 → 2021-12-20 (+2d) | 21d → 20.88d |  | 0d → 18.12d | 37 → 37 SS | resources none → (New Resource) |
| 46 | Oil Separator Drawing | 2021-11-28 → 2021-11-30 (+2d) | 2021-12-18 → 2021-12-20 (+2d) | 21d → 20.88d |  | 0d → 18.12d | 38 → 38 SS | resources none → (New Resource) |
| 47 | Condensor Drawing | 2021-11-21 → 2021-11-30 (+9d) | 2021-12-11 → 2021-12-20 (+9d) | 21d → 20.88d |  | 7d → 18.12d | 39 → 39 SS+30d | resources none → (New Resource) |
| 82 | Material Safety Data Sheet | 2021-11-07 → 2021-11-30 (+23d) | 2021-11-27 → 2021-12-20 (+23d) |  |  | 265d → 241.88d | 34 → 34 FS-16d | resources none → (New Resource) |
| 50 | Economizer Drawing | 2021-11-21 → 2021-11-30 (+9d) | 2021-12-11 → 2021-12-21 (+10d) | 21d → 20.88d |  | 7d → 17.25d | 42 → 42 FS+10d | resources none → (New Resource) |
| 44 | Oil Cooler Drawing | 2021-11-22 → 2021-12-01 (+9d) | 2021-12-12 → 2021-12-21 (+9d) | 21d → 20.88d |  | 6d → 17.12d | 36 → 36 SS+30d | resources none → (New Resource) |
| 64 | Filter Dryer Data Sheet | 2021-11-07 → 2021-12-01 (+24d) | 2021-11-27 → 2021-12-21 (+24d) |  |  | 0d → 17.12d | 34 → 34 FS-15d | resources none → (New Resource) |
| 65 | Filter Dryer Drawing | 2021-11-28 → 2021-12-01 (+3d) | 2021-12-18 → 2021-12-21 (+3d) | 21d → 20.88d |  | 0d → 17.12d | 64 → 64 SS | resources none → (New Resource) |
| 30 | Oil Filter Data Sheet | 2021-11-07 → 2021-12-06 A (+29d) | 2021-11-27 → 2021-12-26 (+29d) |  | 0% → 60% | 0d → 5.88d | 34 → 34 FS-10d | resources none → (New Resource) |
| 43 | Oil Pump Motor Data Sheet | 2021-11-07 → 2021-12-06 (+29d) | 2021-11-27 → 2021-12-26 (+29d) |  |  | 0d → 12.12d | 34 → 34 FS-10d | resources none → (New Resource) |
| 51 | Oil Pump Motor Drawing | 2021-11-28 → 2021-12-06 (+8d) | 2021-12-18 → 2021-12-26 (+8d) | 21d → 20.88d |  | 0d → 12.12d | 43 → 43 SS | resources none → (New Resource) |
| 48 | Liquid Receiver Drawing | 2021-11-28 → 2021-12-07 (+9d) | 2021-12-18 → 2021-12-27 (+9d) | 21d → 20.88d |  | 0d → 11.12d | 40 → 40 SS+10d | resources none → (New Resource) |
| 21 | Instrument Index List (Including Alarm & Trip Points) | 2021-12-12 → 2021-12-11 (-1d) |  |  |  | 23d → 55d |  | resources none → (New Resource) |
| 23 | Control Narrative (Sequence Description) | 2021-12-12 → 2021-12-11 (-1d) |  |  |  | 209d → 229.12d |  | resources none → (New Resource) |
| 54 | Cause and Effect Diagram | 2021-12-12 → 2021-12-11 (-1d) |  |  |  | 107d → 89d |  | resources none → (New Resource) |
| 31 | Oil Filter Drawing | 2021-11-28 → 2021-12-12 (+14d) | 2021-12-18 → 2022-01-01 (+14d) | 21d → 20.88d |  | 0d → 6.12d | 30 → 30 SS+6d | resources none → (New Resource) |
| 49 | K/O Drum Drawing | 2021-11-28 → 2021-12-12 (+14d) | 2021-12-18 → 2022-01-01 (+14d) | 21d → 20.88d |  | 0d → 6.12d |  | resources none → (New Resource) |
| 24 | Spare Parts List for Commissioning & Start-up | 2021-12-24 → 2021-12-13 (-11d) | 2022-01-13 → 2022-01-03 (-10d) |  |  | 239d → 249.12d | 18 → 18 FS-10d | resources none → (New Resource) |
| 25 | Spare Parts List for 2-Year Operation | 2021-12-24 → 2021-12-13 (-11d) | 2022-01-13 → 2022-01-03 (-10d) |  |  | 239d → 249.12d | 18 → 18 FS-10d | resources none → (New Resource) |
| 26 | IOM(including start up, shut down, precommissioning, commissioning procedure) | 2021-12-24 → 2021-12-13 (-11d) | 2022-01-13 → 2022-01-03 (-10d) |  |  | 218d → 246.12d | 18, 59 → 18 FS-10d, 59 FS-10d | resources none → (New Resource) |
| 55 | Operating Manual (Including Start up, Shut Down, Pre-Commissioning, Commissioning Procedure) | 2022-01-14 → 2021-12-16 (-29d) | 2022-02-03 → 2022-01-06 (-28d) |  |  | 218d → 246.12d | 26 → 26 FS-18d | resources none → (New Resource) |
| 73 | Capital Spare Part | 2021-11-14 → 2021-12-18 (+34d) | 2021-12-04 → 2022-01-07 (+34d) |  |  | 279d → 244.88d |  | resources none → (New Resource) |
| 60 | Outline Dimensional Drawings (Cabinets Arrangement) | 2021-12-19 → 2021-12-18 (-1d) |  |  |  | 0d → 0.12d | 18 FS-5d, 34 → 18 FS-5d, 34 FS-5d | resources none → (New Resource) |
| 19 | Mechanical Calculation of Heat Exchangers and Pressure Vessles | 2021-12-05 → 2021-12-19 (+14d) | 2021-12-25 → 2022-01-08 (+14d) | 21d → 20.88d |  | 0d → 6.12d | 31 FS-14d, 44 FS-14d, 45 FS-14d, 46 FS-14d, 47 FS-14d, 48 FS-14d, 49 FS-14d, 50 FS-14d, 51 FS-14d, 65 FS-14d, 57 FS-14d, 35 FS-14d, 34, 85 → 31 FS-14d, 44 FS-14d, 45 FS-14d, 46 FS-14d, 47 FS-14d, 48 FS-14d, 49 FS-14d, 50 FS-14d, 51 FS-14d, 65 FS-14d, 57 FS-14d, 35 FS-14d, 34 FS-49d, 85 FS-14d | resources none → (New Resource) |
| 63 | Noise Data Sheet |  |  | 21d → 20.88d |  |  |  | resources none → (New Resource) |
| 76 | Motor Operation & Maintenance Manual |  |  | 21d → 20.88d |  |  |  | resources none → (New Resource) |
| 78 | Coupling Drawing |  |  | 21d → 20.88d |  |  |  | resources none → (New Resource) |
| 53 | Instrument Data Sheets | 2021-12-12 → 2021-12-21 (+9d) | 2022-01-01 → 2022-01-11 (+10d) |  |  | 0d → 6.12d | 19 FS-14d, 17 → 19 FS-18d, 17 FS-10d | resources none → (New Resource) |
| 22 | Junction Box Connection Diagrams (Including Wire Schematic to Instruments) | 2022-01-02 → 2021-12-22 (-11d) | 2022-01-22 → 2022-01-12 (-10d) |  |  | 23d → 55d | 21, 18 → 21 FS-10d, 18 FS-10d | resources none → (New Resource) |
| 27 | I/O List | 2022-01-02 → 2021-12-22 (-11d) | 2022-01-22 → 2022-01-12 (-10d) |  |  | 230d → 240.12d | 23, 17 → 23 FS-10d, 17 | resources none → (New Resource) |
| 28 | Logic Diagram (Print out PLC Program) | 2022-01-02 → 2021-12-22 (-11d) | 2022-01-22 → 2022-01-12 (-10d) |  |  | 209d → 229.12d | 34, 23 → 34 FS-49d, 23 FS-10d | resources none → (New Resource) |
| 66 | 3D Model | 2021-12-24 → 2021-12-23 (-1d) |  |  |  | 6d → 28d |  | resources none → (New Resource) |
| 70 | MTO of Insulation | 2021-12-24 → 2021-12-23 (-1d) |  |  |  | 12d → 49.12d |  | resources none → (New Resource) |
| 72 | Name Plate Drawing | 2021-12-24 → 2021-12-23 (-1d) |  |  |  | 256d → 258d |  | resources none → (New Resource) |
| 58 | Equipment List |  |  |  |  | 239d → 238.88d | 18, 34 → 18, 34 FS+8d | resources none → (New Resource) |
| 81 | Stress Analysis Report |  |  |  |  | 239d → 238.88d | 61, 18 → 61 FS+8d, 18 | resources none → (New Resource) |
| 80 | Support List | 2021-12-31 → 2021-12-24 (-7d) | 2022-01-20 → 2022-01-14 (-6d) |  |  | 5d → 48.12d | 79 → 79 FS-30d | resources none → (New Resource) |
| 68 | PMS for Compressor Package | 2021-11-07 → 2021-12-27 (+50d) | 2021-11-27 → 2022-01-16 (+50d) |  |  | 209d → 160.75d | 29 → 29 FS+30d | resources none → (New Resource) |

| ID | Task | Start | Finish | Duration | Complete | Total float | Predecessors | Other |
| --- | --- | --- | --- | --- | --- | --- | --- | --- |
| 83 | PSV Data Sheet | 2022-01-02 → 2021-12-28 (-5d) | 2022-01-22 → 2022-01-18 (-4d) |  |  | 162d → 177.88d | 53 → 53 FS-14d | resources none → (New Resource) |
| 56 | Operating / Control Philosophy | 2022-01-23 → 2022-01-02 (-21d) | 2022-02-12 → 2022-01-23 (-20d) |  |  | 209d → 229.12d | 28, 17 → 28 FS-10d, 17 | resources none → (New Resource) |
| 79 | Standard Support | 2021-12-10 → 2022-01-02 (+23d) | 2021-12-30 → 2022-01-23 (+24d) |  |  | 5d → 48.12d | 18 FS-14d → 18 FS+10d | resources none → (New Resource) |
| 77 | ON/OFF Valve Data Sheet | 2022-01-02 → 2022-01-11 (+9d) | 2022-01-22 → 2022-02-01 (+10d) |  |  | 230d → 220d |  | resources none → (New Resource) |
| 75 | LCS Wiring and Drawing | 2022-01-23 → 2022-01-12 (-11d) | 2022-02-12 → 2022-02-02 (-10d) |  |  | 86d → 108d | 22, 34 → 22, 34 FS-39d | resources none → (New Resource) |
| 67 | Line List | 2022-01-14 → 2022-01-13 (-1d) |  |  |  | 218d → 218.12d |  | resources none → (New Resource) |
| 69 | Isometrci Drawing for Interconnecting Piping | 2022-01-14 → 2022-01-13 (-1d) |  |  |  | 6d → 28d |  | resources none → (New Resource) |
| 74 | Special Tools List | 2021-11-14 → 2022-01-17 (+64d) | 2021-12-04 → 2022-02-06 (+64d) |  |  | 279d → 214.88d | 57 → 57 FS+30d | resources none → (New Resource) |
| 62 | Instrument Hook up Drawings | 2021-12-10 → 2022-01-22 (+43d) | 2021-12-30 → 2022-02-12 (+44d) |  |  | 2d → 0d | 34, 18 FS-14d → 34 FS-9d, 18 FS+30d | resources none → (New Resource) |
| 33 | PLC Wiring Diagrams | 2022-01-02 → 2022-01-31 (+29d) | 2022-01-22 → 2022-02-21 (+30d) |  |  | 107d → 89d | 54 → 54 FS+30d | resources none → (New Resource) |
| 16 | Vendor Final Book Index | 2022-02-13 → 2022-02-28 (+15d) | 2022-03-05 → 2022-03-20 (+15d) | 21d → 20.88d |  | 209d → 193.88d |  | resources none → (New Resource) |
| 3 | **QC DOCUMENT** | 2021-10-18 → 2021-11-18 (+31d) | 2022-01-28 → 2022-02-27 (+30d) |  |  |  |  |  |
| 87 | Inspection & Test Plan (ITP) (for Whole Package) | 2021-10-18 → 2021-11-18 (+31d) | 2021-11-07 → 2021-12-08 (+31d) | 0d → 21d |  | 178d → 137.75d | 11 FS+2d → 11 FS+37d | resources none → (New Resource) |
| 92 | NDE Procedure | 2021-11-28 → 2021-11-22 A (-6d) | 2021-12-18 → 2021-12-29 (+11d) |  | 0% → 80% | 227d → 218.75d |  | resources none → (New Resource) |
| 100 | Lifting Procedure | 2021-11-28 → 2021-12-29 (+31d) | 2021-12-18 → 2022-01-18 (+31d) |  |  | 265d → 233.88d |  | resources none → (New Resource) |
| 89 | Painting Procedure | 2021-11-28 → 2021-12-29 (+31d) | 2021-12-18 → 2022-01-18 (+31d) |  |  | 272d → 242.75d |  | resources none → (New Resource) |
| 90 | Packing, Marking and Shipping Procedure | 2021-11-28 → 2021-12-29 (+31d) | 2021-12-18 → 2022-01-18 (+31d) |  |  | 282d → 252.75d |  | resources none → (New Resource) |
| 91 | Fat Procedure for Control System | 2021-11-28 → 2021-12-29 (+31d) | 2021-12-18 → 2022-01-18 (+31d) |  |  | 265d → 233.88d |  | resources none → (New Resource) |
| 93 | PMI Procedure | 2021-11-28 → 2021-12-29 (+31d) | 2021-12-18 → 2022-01-18 (+31d) |  |  | 244d → 212.88d |  | resources none → (New Resource) |
| 95 | Inspection and Test Plan for Compressor | 2021-11-28 → 2021-12-29 A (+31d) | 2021-12-18 → 2021-12-29 (+11d) |  | 0% → 60% | 207d → 253.75d |  | resources none → (New Resource) |
| 97 | Inspection and Test Procedure for Vessle Skids | 2021-11-28 → 2021-12-29 (+31d) | 2021-12-18 → 2022-01-18 (+31d) |  |  | 227d → 197.75d |  | resources none → (New Resource) |
| 96 | Inspection and Test Procedure for Compressor | 2022-01-08 → 2022-01-05 A (-3d) | 2022-01-28 → 2021-12-15 (-44d) |  | 0% → 80% | 207d → 253.75d | 95 FS+20d → 95 FS-14d | resources none → (New Resource) |
| 98 | Preservation Procedure | 2021-12-19 → 2022-01-19 (+31d) | 2022-01-08 → 2022-02-08 (+31d) |  |  | 244d → 212.88d |  | resources none → (New Resource) |
| 99 | Hydrostatic Test Procedure | 2021-11-28 → 2022-01-28 (+61d) | 2021-12-18 → 2022-02-17 (+61d) |  |  | 232d → 172.75d | 87 FS+20d → 87 FS+50d | resources none → (New Resource) |
| 101 | Certificates (Including Welder Qualification Certificate / NDT Personnel Qualification Certificate, etc.) | 2021-11-28 → 2022-02-07 (+71d) | 2021-12-18 → 2022-02-27 (+71d) |  |  | 265d → 193.88d | 87 FS+20d → 87 FS+60d | resources none → (New Resource) |
| 88 | Welding Book (WPS, PQR and Welding / NDE Map) | 2021-11-28 → 2022-02-07 (+71d) | 2021-12-18 → 2022-02-27 (+71d) |  |  | 178d → 137.75d | 87 FS+20d → 87 FS+60d | resources none → (New Resource) |
| 94 | Inspection Notification | 2021-11-28 → 2022-02-07 (+71d) | 2021-12-18 → 2022-02-27 (+71d) |  |  | 275d → 205.75d | 87 FS+20d → 87 FS+60d | resources none → (New Resource) |
| 3 | **Supply of Material** |  | 2022-07-17 → 2022-09-11 (+56d) |  |  |  |  |  |
| 1 | **ForeignSupply** |  | 2022-07-17 → 2022-09-11 (+56d) |  |  |  |  |  |
| 105 | PO placement (Other Valves) |  |  |  |  | 58d → 59.62d | 53, 61 → 53 FS-10d, 61 FS-10d | resources none → (New Resource) |
| 106 | EX Work (Other Valves) |  |  |  |  | 58d → 59.75d |  | resources none → (New Resource) |
| 107 | Custom clearance (Other Valves) |  |  |  |  | 58d → 59.75d |  | resources none → (New Resource) |
| 108 | Delivery to shop (Other Valves) |  |  |  |  | 58d → 59.75d |  | resources none → (New Resource) |
| 2 | **Instrument** | 2022-01-02 → 2022-01-29 (+27d) | 2022-04-16 → 2022-05-14 (+28d) |  |  |  |  |  |
| 110 | PO placement (Instrument) | 2022-01-02 → 2022-01-29 (+27d) | 2022-01-11 → 2022-02-08 (+28d) | 10d → 10.12d |  |  | 53, 52, 62 → 53 FS-14d, 52 FS-14d, 62 FS-14d | resources none → (New Resource) |
| 111 | EX Work (Instrument) | 2022-01-12 → 2022-02-08 (+27d) | 2022-03-12 → 2022-04-09 (+28d) | 60d → 59.88d |  |  |  | resources none → (New Resource) |
| 112 | Custom clearance (Instrument) | 2022-03-13 → 2022-04-09 (+27d) | 2022-04-11 → 2022-05-09 (+28d) | 30d → 30.12d |  |  |  | resources none → (New Resource) |
| 113 | Delivery to shop (Instrument) | 2022-04-12 → 2022-05-09 (+27d) | 2022-04-16 → 2022-05-14 (+28d) | 5d → 4.88d |  |  |  | resources none → (New Resource) |
| 3 | **Electrical (Electro motor)** | 2022-01-09 → 2021-12-29 (-11d) | 2022-07-17 → 2022-09-11 (+56d) |  |  |  |  |  |
| 115 | PO placement (Electrical (Electro motor)) | 2022-01-09 → 2021-12-29 (-11d) | 2022-01-18 → 2022-01-08 (-10d) | 10d → 9.88d |  |  | 32, 34, 35, 60, 76, 78 → 32 FS-10d, 34 FS-49d, 35 FS-10d, 60 FS-10d, 76 FS-10d, 78 FS-10d | resources none → (New Resource) |
| 116 | EX Work (Electrical (Electro motor)) | 2022-01-19 → 2022-01-08 (-11d) | 2022-06-17 → 2022-08-12 (+56d) | 150d → 216d |  |  |  | resources none → (New Resource) |
| 117 | Custom clearance (Electrical (Electro motor)) | 2022-06-18 → 2022-08-12 (+55d) | 2022-07-12 → 2022-09-06 (+56d) |  |  |  |  | resources none → (New Resource) |
| 118 | Delivery to shop (Electrical (Electro motor)) | 2022-07-13 → 2022-09-06 (+55d) | 2022-07-17 → 2022-09-11 (+56d) |  |  |  |  | resources none → (New Resource) |
| 4 | **Filter** | 2021-12-19 → 2021-12-22 (+3d) | 2022-04-02 → 2022-04-06 (+4d) |  |  |  |  |  |
| 120 | PO placement (Filter) | 2021-12-19 → 2021-12-22 (+3d) | 2021-12-28 → 2022-01-01 (+4d) | 10d → 9.88d |  | 132d → 130.12d | 65, 31 → 65 FS-10d, 31 FS-10d | resources none → (New Resource) |
| 121 | EX Work (Filter) | 2021-12-29 → 2022-01-01 (+3d) | 2022-02-26 → 2022-03-02 (+4d) |  |  | 132d → 130d |  | resources none → (New Resource) |
| 122 | Custom clearance (Filter) | 2022-02-27 → 2022-03-02 (+3d) | 2022-03-28 → 2022-04-01 (+4d) |  |  | 132d → 130d |  | resources none → (New Resource) |
| 123 | Delivery to shop (Filter) | 2022-03-29 → 2022-04-01 (+3d) | 2022-04-02 → 2022-04-06 (+4d) |  |  | 132d → 130d |  | resources none → (New Resource) |
| 5 | **Oil pump & Oil separator** | 2021-12-19 → 2021-12-16 (-3d) | 2022-06-16 → 2022-06-04 (-12d) |  |  |  |  |  |
| 126 | EX Work (Oil pump & Oil separator) | 2021-12-29 → 2021-12-16 (-13d) | 2022-05-17 → 2022-05-05 (-12d) |  |  | 8d → 21.88d |  | resources none → (New Resource) |
| 125 | PO placement (Oil pump & Oil separator) | 2021-12-19 A | 2021-12-28 A |  | 0% → 100% | 8d → none | 45, 46, 44, 51 → 45 FS-10d, 46 FS-10d, 44 FS-10d, 51 FS-10d | resources none → (New Resource) |
| 127 | Custom clearance (Oil pump & Oil separator) | 2022-05-18 → 2022-05-05 (-13d) | 2022-06-11 → 2022-05-30 (-12d) |  |  | 8d → 21.88d |  | resources none → (New Resource) |
| 128 | Delivery to shop (Oil pump & Oil separator) | 2022-06-12 → 2022-05-30 (-13d) | 2022-06-16 → 2022-06-04 (-12d) | 5d → 4.88d |  | 8d → 22d |  | resources none → (New Resource) |
| 6 | **Compressor** |  | 2022-05-17 → 2022-07-10 (+54d) |  |  |  |  |  |
| 130 | PO placement (Compressor) | 2021-11-14 A | 2021-11-23 → 2021-11-24 A (+1d) |  | 0% → 100% | 38d → none | 34, 57 → 34 FS-49d, 57 FS-10d | resources none → (New Resource) |
| 131 | EX Work (Compressor) | 2021-11-24 → 2021-12-08 (+14d) | 2022-04-12 → 2022-06-05 (+54d) | 140d → 180d |  | 38d → 5.62d |  | resources none → (New Resource) |
| 132 | Custom clearance (Compressor) | 2022-04-13 → 2022-06-06 (+54d) | 2022-05-12 → 2022-07-05 (+54d) |  |  | 38d → 5.75d |  | resources none → (New Resource) |
| 133 | Delivery to shop (Compressor) | 2022-05-13 → 2022-07-06 (+54d) | 2022-05-17 → 2022-07-10 (+54d) |  |  | 38d → 5.62d |  | resources none → (New Resource) |
| 7 | **Other material** | 2021-12-24 → 2021-12-13 (-11d) | 2022-06-06 → 2022-05-27 (-10d) |  |  |  |  |  |
| 135 | PO placement (other material) | 2021-12-24 → 2021-12-13 (-11d) | 2022-01-02 → 2021-12-23 (-10d) |  |  | 12d → 24d | 18 → 18 FS-10d | resources none → (New Resource) |
| 136 | EX Work (Other material) | 2022-01-03 → 2021-12-23 (-11d) | 2022-05-02 → 2022-04-22 (-10d) |  |  | 12d → 24d |  | resources none → (New Resource) |
| 137 | Custom clearance (Other material) | 2022-05-03 → 2022-04-22 (-11d) | 2022-06-01 → 2022-05-22 (-10d) |  |  | 12d → 24d |  | resources none → (New Resource) |
| 138 | Delivery to shop (Other material) | 2022-06-02 → 2022-05-22 (-11d) | 2022-06-06 → 2022-05-27 (-10d) |  |  | 12d → 24d |  | resources none → (New Resource) |
| 2 | **Domestic Supply** | 2021-12-24 → 2021-12-13 (-11d) | 2022-03-24 → 2022-03-27 (+3d) |  |  |  |  |  |
| 1 | **Pipe** | 2022-02-04 → 2022-01-24 (-11d) | 2022-02-28 → 2022-02-18 (-10d) |  |  |  |  |  |
| 141 | PO placement (Pipe) | 2022-02-04 → 2022-01-24 (-11d) | 2022-02-08 → 2022-01-29 (-10d) | 5d → 4.88d |  | 6d → 28d | 18, 17, 69 → 18 FS-10d, 17 FS-10d, 69 FS-10d | resources none → (New Resource) |
| 142 | EX Work (Pipe) | 2022-02-09 → 2022-01-29 (-11d) | 2022-02-23 → 2022-02-13 (-10d) | 15d → 15.12d |  | 6d → 28d |  | resources none → (New Resource) |
| 143 | Delivery to shop (Pipe) | 2022-02-24 → 2022-02-13 (-11d) | 2022-02-28 → 2022-02-18 (-10d) |  |  | 6d → 28d |  | resources none → (New Resource) |
| 2 | **Plate** | 2021-12-24 → 2021-12-13 (-11d) | 2022-01-17 → 2022-01-07 (-10d) |  |  |  |  |  |
| 145 | PO placement (Plate) | 2021-12-24 → 2021-12-13 (-11d) | 2021-12-28 → 2021-12-18 (-10d) | 5d → 4.88d |  | 48d → 70d | 18 → 18 FS-10d | resources none → (New Resource) |

| ID | Task | Start | Finish | Duration | Total float | Predecessors | Other |
| --- | --- | --- | --- | --- | --- | --- | --- |
| 146 | EX Work (Plate) | 2021-12-29 → 2021-12-18 (-11d) | 2022-01-12 → 2022-01-02 (-10d) | 15d → 15.12d | 48d → 70d |  | resources none → (New Resource) |
| 147 | Delivery to shop (Plate) | 2022-01-13 → 2022-01-02 (-11d) | 2022-01-17 → 2022-01-07 (-10d) |  | 48d → 70d |  | resources none → (New Resource) |
| 3 | **Flange & Fitting** | 2021-12-24 → 2021-12-13 (-11d) | 2022-01-17 → 2022-02-01 (+15d) |  |  |  |  |
| 149 | PO placement (Flange & Fitting) | 2021-12-24 → 2021-12-13 (-11d) | 2021-12-28 → 2021-12-18 (-10d) | 5d → 4.88d | 48d → 45.12d | 18 → 18 FS-10d | resources none → (New Resource) |
| 150 | EX Work (Flange & Fitting) | 2021-12-29 → 2021-12-18 (-11d) | 2022-01-12 → 2022-01-27 (+15d) | 15d → 40.12d | 48d → 45d |  | resources none → (New Resource) |
| 151 | Delivery to shop (Flange & Fitting) | 2022-01-13 → 2022-01-27 (+14d) | 2022-01-17 → 2022-02-01 (+15d) |  | 48d → 45d |  | resources none → (New Resource) |
| 4 | **Gasket** | 2021-12-24 → 2021-12-13 (-11d) | 2022-01-17 → 2022-01-22 (+5d) |  |  |  |  |
| 153 | PO placement (Gasket) | 2021-12-24 → 2021-12-13 (-11d) | 2021-12-28 → 2021-12-18 (-10d) | 5d → 4.88d | 48d → 55.12d | 18 → 18 FS-10d | resources none → (New Resource) |
| 154 | EX Work (Gasket) | 2021-12-29 → 2021-12-18 (-11d) | 2022-01-12 → 2022-01-17 (+5d) | 15d → 30.12d | 48d → 55d |  | resources none → (New Resource) |
| 155 | Delivery to shop (Gasket) | 2022-01-13 → 2022-01-17 (+4d) | 2022-01-17 → 2022-01-22 (+5d) | 5d → 4.88d | 48d → 55.12d |  | resources none → (New Resource) |
| 5 | **Bolt & Nut** | 2021-12-24 → 2021-12-13 (-11d) | 2022-01-17 → 2022-01-22 (+5d) |  |  |  |  |
| 157 | PO placement (Bolt & Nut) | 2021-12-24 → 2021-12-13 (-11d) | 2021-12-28 → 2021-12-18 (-10d) | 5d → 4.88d | 207d → 204.12d | 18 → 18 FS-10d | resources none → (New Resource) |
| 158 | EX Work (Bolt & Nut) | 2021-12-29 → 2021-12-18 (-11d) | 2022-01-12 → 2022-01-17 (+5d) | 15d → 30.12d | 207d → 204d |  | resources none → (New Resource) |
| 159 | Delivery to shop (Bolt & Nut) | 2022-01-13 → 2022-01-17 (+4d) | 2022-01-17 → 2022-01-22 (+5d) | 5d → 4.88d | 207d → 204.12d |  | resources none → (New Resource) |
| 6 | **Electrical** | 2022-01-23 → 2022-01-12 (-11d) | 2022-03-03 → 2022-02-21 (-10d) |  |  |  |  |
| 161 | PO placement (Electrical) | 2022-01-23 → 2022-01-12 (-11d) | 2022-01-27 → 2022-01-17 (-10d) |  | 23d → 55d | 18, 22 → 18 FS-10d, 22 | resources none → (New Resource) |
| 162 | EX Work (Electrical) | 2022-01-28 → 2022-01-17 (-11d) | 2022-02-26 → 2022-02-16 (-10d) |  | 23d → 55d |  | resources none → (New Resource) |
| 163 | Delivery to shop (Electrical) | 2022-02-27 → 2022-02-16 (-11d) | 2022-03-03 → 2022-02-21 (-10d) |  | 23d → 55d |  | resources none → (New Resource) |
| 7 | **Manual valves** | 2022-01-23 → 2022-01-09 (-14d) | 2022-03-03 → 2022-02-17 (-14d) |  |  |  |  |
| 165 | PO placement (Manual valves) | 2022-01-23 → 2022-01-09 (-14d) | 2022-01-27 → 2022-01-13 (-14d) |  | 162d → 177.75d | 18, 61, 83 → 18 FS-10d, 61 FS-10d, 83 FS-10d | resources none → (New Resource) |
| 166 | EX Work (Manual valves) | 2022-01-28 → 2022-01-14 (-14d) | 2022-02-26 → 2022-02-12 (-14d) | 30d → 29.88d | 162d → 177.88d |  | resources none → (New Resource) |
| 167 | Delivery to shop (Manual valves) | 2022-02-27 → 2022-02-13 (-14d) | 2022-03-03 → 2022-02-17 (-14d) |  | 162d → 177.75d |  | resources none → (New Resource) |
| 8 | **Instrument** | 2022-01-02 → 2022-02-15 (+44d) | 2022-02-10 → 2022-03-27 (+45d) |  |  |  |  |
| 169 | PO placement (Domestic Instrument) | 2022-01-02 → 2022-02-15 (+44d) | 2022-01-06 → 2022-02-20 (+45d) |  | 24d → 6d | 53, 18 → 53 FS+35d, 18 FS+35d | resources none → (New Resource) |
| 170 | EX Work (Domestic Instrument) | 2022-01-07 → 2022-02-20 (+44d) | 2022-02-05 → 2022-03-22 (+45d) | 30d → 29.88d | 24d → 6.12d |  | resources none → (New Resource) |
| 171 | Delivery to shop (Domestic Instrument) | 2022-02-06 → 2022-03-22 (+44d) | 2022-02-10 → 2022-03-27 (+45d) |  | 24d → 6d |  | resources none → (New Resource) |
| 9 | **PLC** | 2022-02-13 → 2022-02-11 (-2d) | 2022-03-24 → 2022-03-23 (-1d) |  |  |  |  |
| 173 | PO placement (PLC) | 2022-02-13 → 2022-02-11 (-2d) | 2022-02-17 → 2022-02-16 (-1d) |  | 86d → 89d | 33, 18, 75 → 33 FS-10d, 18 FS-10d, 75 FS-10d | resources none → (New Resource) |
| 174 | EX Work (PLC) | 2022-02-18 → 2022-02-16 (-2d) | 2022-03-19 → 2022-03-18 (-1d) |  | 86d → 89d |  | resources none → (New Resource) |
| 175 | Delivery to shop (PLC) | 2022-03-20 → 2022-03-18 (-2d) | 2022-03-24 → 2022-03-23 (-1d) |  | 86d → 89d |  | resources none → (New Resource) |
| 10 | **Other material** | 2022-01-21 → 2022-01-04 (-17d) | 2022-03-01 → 2022-02-13 (-16d) |  |  |  |  |
| 177 | PO placement (Other material (Domestic) ) | 2022-01-21 → 2022-01-04 (-17d) | 2022-01-25 → 2022-01-09 (-16d) |  | 5d → 48d | 18, 70, 80 → 18 FS-10d, 70 FS-10d, 80 FS-10d | resources none → (New Resource) |
| 178 | EX Work (Other material(Domestic)) | 2022-01-26 → 2022-01-09 (-17d) | 2022-02-24 → 2022-02-08 (-16d) |  | 5d → 48.12d |  | resources none → (New Resource) |
| 179 | Delivery to shop (Other material(Domestic)) | 2022-02-25 → 2022-02-08 (-17d) | 2022-03-01 → 2022-02-13 (-16d) |  | 5d → 48d |  | resources none → (New Resource) |
| 4 | **Fabrication** | 2022-01-18 → 2022-01-07 (-11d) | 2022-09-26 → 2022-09-28 (+2d) |  |  |  |  |
| 214 | Visual & DIM. Inspection | 2022-09-14 → 2022-09-15 (+1d) | 2022-09-16 → 2022-09-18 (+2d) |  |  |  | resources none → (New Resource) |
| 215 | Surface Preparation | 2022-09-17 → 2022-09-18 (+1d) | 2022-09-19 → 2022-09-21 (+2d) |  |  |  | resources none → (New Resource) |
| 216 | Painting | 2022-09-20 → 2022-09-21 (+1d) | 2022-09-24 → 2022-09-26 (+2d) |  |  |  | resources none → (New Resource) |
| 217 | Final Check | 2022-09-25 → 2022-09-26 (+1d) | 2022-09-26 → 2022-09-28 (+2d) |  |  |  | resources none → (New Resource) |
| 1 | **Fabrication For Compressor unit** | 2022-03-02 → 2022-03-12 (+10d) | 2022-08-28 → 2022-08-24 (-4d) |  |  |  |  |
| 183 | Oil filter | 2022-03-02 → 2022-03-12 (+10d) | 2022-07-09 → 2022-07-10 (+1d) | 130d → 120.12d | 5d → 5.75d | 143, 147, 151, 155, 179, 171 → 143, 147, 151, 155, 179 FS-15d, 171 FS-15d | resources none → (New Resource) |
| 184 | Oil cooler | 2022-03-02 → 2022-03-12 (+10d) | 2022-07-09 → 2022-07-10 (+1d) | 130d → 120.12d | 5d → 5.75d | 143, 147, 151, 155, 179, 171 → 143, 147, 151, 155, 179 FS-15d, 171 FS-15d | resources none → (New Resource) |
| 185 | Filter dryer | 2022-03-02 → 2022-03-12 (+10d) | 2022-07-09 → 2022-07-10 (+1d) | 130d → 120.12d | 5d → 5.75d | 143, 147, 151, 155, 179, 171 → 143, 147, 151, 155, 179 FS-15d, 171 FS-15d | resources none → (New Resource) |
| 182 | Compressor unit Fabrication | 2022-06-25 → 2022-06-04 (-21d) | 2022-07-14 → 2022-06-24 (-20d) | 20d → 20.12d | 0d → 21.75d | 133, 128, 118 FS-23d, 113, 171, 68 → 128, 113, 171, 68 | resources none → (New Resource) |
| 186 | Part Assembly | 2022-07-15 → 2022-07-11 (-4d) | 2022-08-03 → 2022-07-30 (-4d) | 20d → 19.88d | 0d → 5.88d | 183, 184, 185, 182 → 183, 184, 185, 182, 133 | resources none → (New Resource) |
| 187 | Part Welding | 2022-08-04 → 2022-07-31 (-4d) | 2022-08-23 → 2022-08-19 (-4d) |  | 0d → 5.75d |  | resources none → (New Resource) |
| 188 | Running test | 2022-08-24 → 2022-08-20 (-4d) | 2022-08-28 → 2022-08-24 (-4d) |  | 0d → 5.75d |  | resources none → (New Resource) |
| 2 | **Fabrication For Condensor** | 2022-03-27 → 2022-03-06 (-21d) | 2022-08-12 → 2022-06-22 (-51d) |  |  |  |  |
| 190 | Part Fabrication-(cutting,rolling,casting) | 2022-03-27 → 2022-03-06 (-21d) | 2022-04-25 → 2022-04-05 (-20d) | 30d → 30.12d | 0d → 52.88d | 143, 147, 151, 155, 163, 171, 113 FS-21d, 47 → 143, 147, 151, 155, 163 FS-21d, 171 FS-21d, 47 | resources none → (New Resource) |
| 191 | Part Assembly | 2022-04-26 → 2022-04-05 (-21d) | 2022-06-14 → 2022-05-25 (-20d) |  | 0d → 53d |  | resources none → (New Resource) |
| 192 | Part Welding | 2022-06-15 → 2022-05-25 (-21d) | 2022-08-09 → 2022-06-19 (-51d) | 25d → 24.88d | 0d → 53d |  | resources none → (New Resource) |
| 193 | NDT Condensor | 2022-08-10 → 2022-06-19 (-52d) | 2022-08-12 → 2022-06-22 (-51d) |  | 0d → 53d |  | resources none → (New Resource) |
| 3 | **Fabrication For Hexane chiller** | 2022-03-31 → 2022-04-17 (+17d) | 2022-08-12 → 2022-08-30 (+18d) |  |  |  |  |
| 195 | Part Fabrication-(cutting,rolling,casting) | 2022-03-31 → 2022-04-17 (+17d) | 2022-05-09 → 2022-05-27 (+18d) |  |  | 143, 147, 151, 155, 163, 171, 113 FS-17d → 143, 147, 151, 155, 163, 171 FS-15d, 113 FS-27d | resources none → (New Resource) |
| 196 | Part Assembly | 2022-05-10 → 2022-05-27 (+17d) | 2022-07-13 → 2022-07-31 (+18d) |  |  |  | resources none → (New Resource) |
| 197 | Part Welding | 2022-07-14 → 2022-07-31 (+17d) | 2022-08-07 → 2022-08-25 (+18d) |  |  |  | resources none → (New Resource) |
| 198 | NDT Hexane chiller | 2022-08-08 → 2022-08-25 (+17d) | 2022-08-12 → 2022-08-30 (+18d) |  |  |  | resources none → (New Resource) |
| 4 | **Fabrication For Skid** | 2022-01-18 → 2022-01-07 (-11d) | 2022-03-28 → 2022-03-29 (+1d) |  |  |  |  |
| 200 | Part Fabrication-(cutting,rolling,casting) | 2022-01-18 → 2022-01-07 (-11d) | 2022-02-06 → 2022-01-27 (-10d) |  | 137d → 148.88d |  | resources none → (New Resource) |
| 201 | Part Assembly | 2022-02-07 → 2022-01-27 (-11d) | 2022-02-26 → 2022-02-16 (-10d) |  | 137d → 149d |  | resources none → (New Resource) |
| 202 | Part Welding | 2022-02-27 → 2022-02-28 (+1d) | 2022-03-18 → 2022-03-19 (+1d) | 20d → 19.88d | 137d → 137.88d |  | resources none → (New Resource) |
| 203 | NDT Skid | 2022-03-19 → 2022-03-20 (+1d) | 2022-03-28 → 2022-03-29 (+1d) |  | 137d → 137.75d |  | resources none → (New Resource) |
| 5 | **Fabrication For Other** | 2022-06-11 → 2022-05-29 (-13d) | 2022-08-04 → 2022-07-23 (-12d) |  |  |  |  |
| 205 | Part Fabrication-(cutting,rolling,casting) | 2022-06-11 → 2022-05-29 (-13d) | 2022-06-30 → 2022-06-18 (-12d) | 20d → 19.88d | 8d → 22.12d |  | resources none → (New Resource) |
| 206 | Part Assembly | 2022-07-01 → 2022-06-18 (-13d) | 2022-07-15 → 2022-07-03 (-12d) | 15d → 15.12d | 8d → 22d |  | resources none → (New Resource) |
| 207 | Part Welding | 2022-07-16 → 2022-07-03 (-13d) | 2022-07-30 → 2022-07-18 (-12d) |  | 8d → 22d |  | resources none → (New Resource) |
| 208 | Hydro test | 2022-07-31 → 2022-07-18 (-13d) | 2022-08-04 → 2022-07-23 (-12d) | 5d → 4.88d | 8d → 22.12d |  | resources none → (New Resource) |
| 6 | **Assembly of packages on skid** | 2022-08-13 → 2022-08-14 (+1d) | 2022-09-13 → 2022-09-15 (+2d) |  |  |  |  |
| 210 | Inter connecting piping | 2022-08-13 → 2022-08-14 (+1d) | 2022-08-27 → 2022-08-29 (+2d) |  |  | 188 FS-16d, 193, 198, 203, 167, 108, 123, 159, 208 → 188 FS-16d, 193, 198 FS-16d, 203, 167, 108, 123, 159, 208, 118 FS-28d | resources none → (New Resource) |
| 211 | Part Assembly | 2022-08-28 → 2022-08-29 (+1d) | 2022-09-01 → 2022-09-03 (+2d) | 5d → 4.88d |  |  | resources none → (New Resource) |

| ID | Task | Start | Finish | Duration | Predecessors | Other |
| --- | --- | --- | --- | --- | --- | --- |
| 212 | Part Welding | 2022-09-02 → 2022-09-03 (+1d) | 2022-09-08 → 2022-09-10 (+2d) |  | 211, 88 → 211, 88 FS-10d | resources none → (New Resource) |
| 213 | NDT packages on skid | 2022-09-09 → 2022-09-10 (+1d) | 2022-09-13 → 2022-09-15 (+2d) | 5d → 5.12d |  | resources none → (New Resource) |
| 5 | **FINAL INSPECTION TEST and RELEASE NOTE for Ex-Work** | 2022-09-27 → 2022-09-28 (+1d) |  |  |  |  |
| 219 | FINAL INSPECTION TEST and RELEASE NOTE for Ex-Work | 2022-09-27 → 2022-09-28 (+1d) |  | 4d → 2d |  | resources none → (New Resource) |
| 6 | **Final Data Book** | 2022-10-01 → 2022-09-30 (-1d) |  |  |  |  |
| 221 | VENDOR FINAL DATA BOOK | 2022-10-01 → 2022-09-30 (-1d) |  | 4d → 4.12d |  | resources none → (New Resource) |

## Version 3 (data date 2021-12-16, saved 2021-12-21, file DPIC-PO-NEC-299-R1-2.xer)

Last finish stays 2022-10-04. Complete tasks 2 → 4.

Changed:

| ID | Task | Start | Complete |
| --- | --- | --- | --- |
| 14 | Sub Vendor List | 2021-09-19 A | 0% → 80% |
| 12 | Time Schedule |  | 60% → 100% |
| 18 | General Arrangement Drawing Including Loads, Displacement, and Maintenace Info | 2021-11-23 A | 0% → 60% |
| 64 | Filter Dryer Data Sheet | 2021-12-01 A | 0% → 80% |
| 30 | Oil Filter Data Sheet |  | 60% → 80% |
| 49 | K/O Drum Drawing | 2021-12-12 A | 0% → 60% |
| 115 | PO placement (Electrical (Electro motor)) | 2021-12-29 A | 0% → 100% |

## Version 4 (data date 2022-01-15, saved 2022-01-16, file DPIC-PO-NEC-299-R1-3.xer)

Last finish stays 2022-10-04.

Changed:

| ID | Task | Start | Complete | Total float | Other |
| --- | --- | --- | --- | --- | --- |
| 13 | Project Monthly Report for Refrigeration Packages |  | 60% → 80% |  |  |
| 39 | Condenser Data Sheet |  |  |  | was named Condensor Data Sheet |
| 42 | Economizer Data Sheet | 2021-10-31 A | 0% → 80% |  |  |
| 71 | Thermal Calculation for Heat Exchangers | 2021-10-31 A | 0% → 80% |  |  |
| 18 | General Arrangement Drawing Including Loads, Displacement, and Maintenace Info |  | 60% → 80% |  |  |
| 20 | Utility Consumption List | 2021-11-27 A | 0% → 60% |  |  |
| 57 | Compressor Data Sheet | 2021-11-27 A | 0% → 60% |  |  |
| 85 | Evaporator Drawing | 2021-11-27 A | 0% → 60% |  |  |
| 37 | Oil Pump Data Sheet | 2021-11-30 A | 0% → 60% |  |  |
| 45 | Oil Pump Drawing | 2021-11-30 A | 0% → 80% |  |  |
| 47 | Condensor Drawing | 2021-11-30 A | 0% → 60% |  |  |
| 50 | Economizer Drawing | 2021-11-30 A | 0% → 80% |  |  |
| 44 | Oil Cooler Drawing | 2021-12-01 A | 0% → 80% |  |  |
| 65 | Filter Dryer Drawing | 2021-12-01 A | 0% → 60% |  |  |
| 48 | Liquid Receiver Drawing | 2021-12-07 A | 0% → 60% |  |  |
| 21 | Instrument Index List (Including Alarm & Trip Points) | 2021-12-11 A | 0% → 60% |  |  |
| 24 | Spare Parts List for Commissioning & Start-up | 2021-12-13 A | 0% → 60% | 249.12d → none |  |
| 25 | Spare Parts List for 2-Year Operation | 2021-12-13 A | 0% → 60% |  |  |
| 73 | Capital Spare Part | 2021-12-18 A | 0% → 60% |  |  |
| 19 | Mechanical Calculation of Heat Exchangers and Pressure Vessles | 2021-12-19 A | 0% → 80% |  |  |
| 78 | Coupling Drawing | 2021-12-19 A | 0% → 80% |  |  |
| 31 | Oil Filter Drawing | 2021-12-12 → 2022-01-03 A (+22d) | 0% → 60% |  |  |
| 87 | Inspection & Test Plan (ITP) (for Whole Package) | 2021-11-18 A | 0% → 80% |  |  |
| 116 | EX Work (Electrical (Electro motor)) | 2022-01-08 A | 0% → 15% |  |  |
| 120 | PO placement (Filter) | 2021-12-22 A |  |  |  |
| 126 | EX Work (Oil pump & Oil separator) | 2021-12-16 A | 0% → 15% |  |  |
| 131 | EX Work (Compressor) | 2021-12-08 A | 0% → 15% |  |  |

## Version 5 (data date 2022-02-14, saved 2022-02-19, file DPIC-PO-NEC-299-R2-4.xer)

Last finish stays 2022-10-04. Complete tasks 4 → 6.

Added:

| ID | Task | Duration | Start | Finish | Resources |
| --- | --- | --- | --- | --- | --- |
| 7 | **Fabrication status for foreign supply** |  | 2021-11-14 | 2022-09-11 |  |
| A1020 | Compressor | 239d | 2021-11-14 A | 2022-07-10 | (New Resource) [1912 h] |
| A1010 | Oil pump & Oil Seprator | 160d | 2021-12-19 A | 2022-06-04 | (New Resource) [168 h] |
| A1000 | Electro motor | 233d | 2021-12-29 A | 2022-09-11 | (New Resource) [1838.91 h] |

Changed:

| ID | Task | Start | Complete | Other |
| --- | --- | --- | --- | --- |
| 39 | Condenser Data Sheet | 2021-10-31 A | 0% → 80% |  |
| 36 | Oil Cooler Data Sheet | 2021-11-01 A | 0% → 80% |  |
| 84 | Evaporator Data Sheet | 2021-11-07 A | 0% → 80% |  |
| 17 | Piping and Instrument Diagram (PID) |  | 60% → 80% |  |
| 41 | K/O Drum Data Sheet | 2021-11-21 A | 0% → 80% |  |
| 20 | Utility Consumption List |  | 60% → 80% |  |
| 40 | Liquid Receiver Data Sheet | 2021-11-27 A | 0% → 80% |  |
| 57 | Compressor Data Sheet |  | 60% → 80% |  |
| 85 | Evaporator Drawing |  | 60% → 80% |  |
| 32 | Main Motor Data Sheet and Curve | 2021-11-28 A | 0% → 60% |  |
| 37 | Oil Pump Data Sheet |  | 60% → 80% |  |
| 47 | Condenser Drawing |  | 60% → 80% | was named Condensor Drawing |
| 64 | Propylene Filter Dryer Data Sheet |  |  | was named Filter Dryer Data Sheet |
| 65 | Filter Dryer Drawing |  | 60% → 80% |  |
| 48 | Liquid Receiver Drawing |  | 60% → 80% |  |
| 21 | Instrument Index List (Including Alarm & Trip Points) |  | 60% → 80% |  |
| 49 | K/O Drum Drawing |  | 60% → 80% |  |
| 58 | Equipment List | 2021-12-24 A | 0% → 60% |  |
| 31 | Oil Filter Drawing |  | 60% → 80% |  |
| 67 | Line List | 2022-01-13 A | 0% → 80% |  |
| 92 | NDE Procedure |  | 80% → 100% |  |
| 90 | Packing, Marking and Shipping Procedure | 2021-12-29 A | 0% → 80% |  |
| 93 | PMI Procedure | 2021-12-29 A | 0% → 100% |  |
| 101 | Certificates (Including Welder Qualification Certificate / NDT Personnel Qualification Certificate, etc.) | 2022-02-07 A | 0% → 80% |  |
| 116 | EX Work (Electrical (Electro motor)) |  | 15% → 0% |  |
| 126 | EX Work (Oil pump & Oil separator) |  | 15% → 0% |  |
| 131 | EX Work (Compressor) |  | 15% → 0% |  |
| 4 | **Fabrication** | 2022-01-07 → 2021-11-14 (-54d) |  |  |
